# Factory Facelift #1

Schedule from MS Project, 2004-06-16 to 2004-07-14.

## Calendars

- Standard: Mon-Fri 08:00-12:00, 13:00-17:00; Sat-Sun off.

## Resources

| Resource | Group | Rate | Cost per use |
| --- | --- | --- | --- |
| Whelan Wreckers | Construction | 80 |  |
| B & G Construction | Construction | 45 |  |
| Empire Glasswork | Glasswork |  | 1800 |
| Paula's Gardening | Gardening | 30 |  |

## Schedule

| ID | WBS | Task | Type | Duration | Start | Finish | Predecessors | Total slack |
| --- | --- | --- | --- | --- | --- | --- | --- | --- |
| 1 | 1 | **Factory Facelift** |  | 20.38d | 2004-06-16 | 2004-07-14 |  | 0d |
| 2 | 1.1 | **Build Façade** |  | 11d | 2004-06-16 | 2004-06-30 |  | 0d |
| 3 | 1.1.1 | Remove old exterior |  | 4d | 2004-06-16 | 2004-06-21 |  | 0d |
| 4 | 1.1.2 | Erect framework |  | 3d | 2004-06-22 | 2004-06-24 | 3 | 0d |
| 5 | 1.1.3 | Add glasswork |  | 2d | 2004-06-25 | 2004-06-28 | 4 | 0d |
| 6 | 1.1.4 | Erect/paint new walls |  | 2d | 2004-06-29 | 2004-06-30 | 5 | 0d |
| 7 | 1.2 | **Landscape Garden** |  | 7d | 2004-07-01 | 2004-07-09 |  | 0d |
| 8 | 1.2.1 | Clear debris |  | 1d | 2004-07-01 | 2004-07-01 | 6 | 0d |
| 9 | 1.2.2 | Add topsoil |  | 1d | 2004-07-02 | 2004-07-02 | 8 | 0d |
| 10 | 1.2.3 | Lay lawns |  | 2d | 2004-07-05 | 2004-07-06 | 9 | 0d |
| 11 | 1.2.4 | Plant trees and flower beds |  | 3d | 2004-07-07 | 2004-07-09 | 10 | 0d |
| 12 | 1.3 | **Erect Fountain** |  | 2d | 2004-07-12 | 2004-07-13 |  | 0d |
| 13 | 1.3.1 | Assemble fountain |  | 12h | 2004-07-12 | 2004-07-13 | 11 | 0d |
| 14 | 1.3.2 | Connect plumbing |  | 4h | 2004-07-13 | 2004-07-13 | 13 | 0d |
| 15 | 1.4 | **Erect Flagpole** |  | 0.38d | 2004-07-14 | 2004-07-14 |  | 0d |
| 16 | 1.4.1 | Construct footing |  | 2h | 2004-07-14 | 2004-07-14 | 14 | 0d |
| 17 | 1.4.2 | Attach flagpole |  | 1h | 2004-07-14 | 2004-07-14 | 16 | 0d |
| 18 | 1.5 | Project Completed | milestone | 0d | 2004-07-14 | 2004-07-14 | 17 | 0d |
